# NEW_EXONE_1

How a schedule from MS Project changed from version to version. A marks actual dates.

## Version 1 (saved 2016-12-29, file EXONE_CONTRACTOR_PLAN.mpp)

| ID | WBS | Task | Duration | Start | Finish | Predecessors | Total float | Constraint |
| --- | --- | --- | --- | --- | --- | --- | --- | --- |
| 1 | 1 | **PROJECT EXONE** | 65d | 2017-01-03 | 2017-04-03 |  | 0d | start no earlier than 2011-01-03 |
| 2 | 1.1 | **REQUIREMENTS** | 4d | 2017-01-03 | 2017-01-06 |  | 0d |  |
| 3 |  | Review and complete requirements & plan with client | 3d | 2017-01-03 | 2017-01-05 |  |  |  |
| 4 |  | Final discussion and agreement with client on req'ts & plan | 1d | 2017-01-06 | 2017-01-06 | 3 | 0d |  |
| 5 | 1.2 | **DESIGN** | 11d | 2017-01-09 | 2017-01-23 |  | 0d |  |
| 6 |  | Write design specifications | 7d | 2017-01-09 | 2017-01-17 | 4 | 0d |  |
| 7 |  | Check design with respect to requirements | 2d | 2017-01-18 | 2017-01-19 | 6 | 0d |  |
| 8 |  | Meet with client to discuss & agree on design | 2d | 2017-01-20 | 2017-01-23 | 7 | 0d |  |
| 9 | 1.3 | **IMPLEMENTATION** | 46d | 2017-01-24 | 2017-03-28 |  | 0d |  |
| 10 |  | Coding - Alpha version | 7d | 2017-01-24 | 2017-02-01 | 8 | 2d |  |
| 11 |  | Debugging phase 1 (following internal Alpha testing) | 3d | 2017-02-06 | 2017-02-08 | 27, 10 | 0d |  |
| 12 |  | Production of Alpha version and delivery to client | 1d | 2017-02-10 | 2017-02-10 | 22 | 0d |  |
| 13 |  | Debugging phase 2 (following client Alpha testing) | 2d | 2017-02-15 | 2017-02-16 | 28 | 0d |  |
| 14 |  | Coding - Beta version | 8d | 2017-02-17 | 2017-02-28 | 13 | 0d |  |
| 15 |  | Debugging phase 3 (following internal Beta testing) | 3d | 2017-03-02 | 2017-03-06 | 29, 14 | 0d |  |
| 16 |  | Production of Beta version and delivery to client | 1d | 2017-03-09 | 2017-03-09 | 24 | 0d |  |
| 17 |  | Debugging phase 4 (following client Beta testing) | 4d | 2017-03-16 | 2017-03-21 | 30 | 0d |  |
| 18 |  | Production of Final version and delivery to client | 1d | 2017-03-22 | 2017-03-22 | 17 | 0d |  |
| 19 |  | Debugging phase 5 & delivery (following client Final testing) | 2d | 2017-03-27 | 2017-03-28 | 31 | 0d |  |
| 20 | 1.4 | **INTEGRATION** | 23d | 2017-02-06 | 2017-03-08 |  | 0d |  |
| 21 |  | Delivery of content subset by client | 1d | 2017-02-06 | 2017-02-06 | 11FF-2d | 2d |  |
| 22 |  | Integration of content subset | 1d | 2017-02-09 | 2017-02-09 | 21, 11 | 0d |  |
| 23 |  | Delivery of complementary content by client | 1d | 2017-03-02 | 2017-03-02 | 15FF-2d | 2d |  |
| 24 |  | Integration of complementary content | 2d | 2017-03-07 | 2017-03-08 | 23, 15 | 0d |  |
| 25 | 1.5 | **TESTING & ACCEPTANCE** | 47d | 2017-01-24 | 2017-03-29 |  | 0d |  |
| 26 |  | Prepare test plan and test cases | 5d | 2017-01-24 | 2017-01-30 | 8 | 0d |  |
| 27 |  | Internal testing - Alpha version | 4d | 2017-01-31 | 2017-02-03 | 10SS+3d, 26 | 0d |  |
| 28 |  | Alpha testing by client | 2d | 2017-02-13 | 2017-02-14 | 12 | 0d |  |
| 29 |  | Internal testing - Beta version | 4d | 2017-02-24 | 2017-03-01 | 14SS+5d | 0d |  |
| 30 |  | Beta testing by client | 4d | 2017-03-10 | 2017-03-15 | 16 | 0d |  |
| 31 |  | Final testing by client | 2d | 2017-03-23 | 2017-03-24 | 18 | 0d |  |
| 32 |  | Acceptance by client | 1d | 2017-03-29 | 2017-03-29 | 19 | 0d |  |
| 33 |  | DEPLOYMENT AT CLIENT'S SITE | 2d | 2017-03-30 | 2017-03-31 | 32 | 0d |  |
| 34 |  | PROJECT MANAGEMENT (After Req'ts WP & before Closure) | 60d | 2017-01-09 | 2017-03-31 | 2, 33FF | 0d | start no earlier than 2012-01-06 |
| 35 |  | PROJECT CLOSURE | 1d | 2017-04-03 | 2017-04-03 | 34 | 0d |  |

## Version 2 (saved 2016-12-29, file EXONE_CONTRACTOR_WORK_PROGRESS.mpp)

Last finish stays 2017-04-03. Complete tasks 0 → 14.

Changed:

| ID | Task | Start | Finish | Duration | Complete | Total float | Other |
| --- | --- | --- | --- | --- | --- | --- | --- |
| 1 | **PROJECT EXONE** | 2017-01-03 A |  | 65d → 64.5d | 0% → 57% |  | baseline start none → 2017-01-03; baseline finish none → 2017-04-03 |
| 2 | **REQUIREMENTS** | 2017-01-03 A | 2017-01-06 A | 4d → 3.5d | 0% → 100% | 0d → none | baseline start none → 2017-01-03; baseline finish none → 2017-01-06 |
| 3 | Review and complete requirements & plan with client | 2017-01-03 A | 2017-01-05 A | 3d → 2.5d | 0% → 100% |  | baseline start none → 2017-01-03; baseline finish none → 2017-01-05 |
| 4 | Final discussion and agreement with client on req'ts & plan | 2017-01-06 A | 2017-01-06 A | 1d → 0.5d | 0% → 100% | 0d → none | baseline start none → 2017-01-06; baseline finish none → 2017-01-06 |
| 5 | **DESIGN** | 2017-01-09 → 2017-01-06 A (-3d) | 2017-01-23 → 2017-01-20 A (-3d) | 11d → 10d | 0% → 100% | 0d → none | baseline start none → 2017-01-09; baseline finish none → 2017-01-23 |
| 6 | Write design specifications | 2017-01-09 → 2017-01-06 A (-3d) | 2017-01-17 → 2017-01-16 A (-1d) | 7d → 6d | 0% → 100% | 0d → none | baseline start none → 2017-01-09; baseline finish none → 2017-01-17 |
| 7 | Check design with respect to requirements | 2017-01-18 → 2017-01-16 A (-2d) | 2017-01-19 → 2017-01-18 A (-1d) |  | 0% → 100% | 0d → none | baseline start none → 2017-01-18; baseline finish none → 2017-01-19 |
| 8 | Meet with client to discuss & agree on design | 2017-01-20 → 2017-01-18 A (-2d) | 2017-01-23 → 2017-01-20 A (-3d) |  | 0% → 100% | 0d → none | baseline start none → 2017-01-20; baseline finish none → 2017-01-23 |
| 9 | **IMPLEMENTATION** | 2017-01-24 → 2017-01-20 A (-4d) | 2017-03-28 → 2017-03-24 (-4d) | 46d → 45.5d | 0% → 56% | 0d → 1.5d | baseline start none → 2017-01-24; baseline finish none → 2017-03-28 |
| 10 | Coding - Alpha version | 2017-01-24 → 2017-01-20 A (-4d) | 2017-02-01 → 2017-01-30 A (-2d) | 7d → 6d | 0% → 100% | 2d → none | baseline start none → 2017-01-24; baseline finish none → 2017-02-01 |
| 11 | Debugging phase 1 (following internal Alpha testing) | 2017-02-06 → 2017-02-02 A (-4d) | 2017-02-08 → 2017-02-07 A (-1d) |  | 0% → 100% | 0d → none | baseline start none → 2017-02-06; baseline finish none → 2017-02-08 |
| 12 | Production of Alpha version and delivery to client | 2017-02-10 → 2017-02-08 A (-2d) | 2017-02-10 → 2017-02-09 A (-1d) |  | 0% → 100% | 0d → none | baseline start none → 2017-02-10; baseline finish none → 2017-02-10 |
| 13 | Debugging phase 2 (following client Alpha testing) | 2017-02-15 → 2017-02-13 A (-2d) | 2017-02-16 → 2017-02-14 A (-2d) | 2d → 1.5d | 0% → 100% | 0d → none | baseline start none → 2017-02-15; baseline finish none → 2017-02-16 |
| 14 | Coding - Beta version | 2017-02-17 → 2017-02-15 A (-2d) | 2017-02-28 → 2017-02-27 (-1d) | 8d → 9d | 0% → 67% | 0d → 24.5d | baseline start none → 2017-02-17; baseline finish none → 2017-02-28 |
| 15 | Debugging phase 3 (following internal Beta testing) | 2017-03-02 → 2017-02-28 (-2d) | 2017-03-06 → 2017-03-02 (-4d) |  |  | 0d → 1.5d | baseline start none → 2017-03-02; baseline finish none → 2017-03-06 |
| 16 | Production of Beta version and delivery to client | 2017-03-09 → 2017-03-07 (-2d) | 2017-03-09 → 2017-03-07 (-2d) |  |  | 0d → 1.5d | baseline start none → 2017-03-09; baseline finish none → 2017-03-09 |
| 17 | Debugging phase 4 (following client Beta testing) | 2017-03-16 → 2017-03-14 (-2d) | 2017-03-21 → 2017-03-17 (-4d) |  |  | 0d → 1.5d | baseline start none → 2017-03-16; baseline finish none → 2017-03-21 |
| 18 | Production of Final version and delivery to client | 2017-03-22 → 2017-03-20 (-2d) | 2017-03-22 → 2017-03-20 (-2d) |  |  | 0d → 1.5d | baseline start none → 2017-03-22; baseline finish none → 2017-03-22 |
| 19 | Debugging phase 5 & delivery (following client Final testing) | 2017-03-27 → 2017-03-23 (-4d) | 2017-03-28 → 2017-03-24 (-4d) |  |  | 0d → 1.5d | baseline start none → 2017-03-27; baseline finish none → 2017-03-28 |
| 20 | **INTEGRATION** | 2017-02-06 → 2017-02-02 A (-4d) | 2017-03-08 → 2017-03-06 (-2d) | 23d → 22.5d | 0% → 40% | 0d → 1.5d | baseline start none → 2017-02-06; baseline finish none → 2017-03-08 |
| 21 | Delivery of content subset by client | 2017-02-06 → 2017-02-02 A (-4d) | 2017-02-06 → 2017-02-03 A (-3d) |  | 0% → 100% | 2d → none | baseline start none → 2017-02-06; baseline finish none → 2017-02-06 |
| 22 | Integration of content subset | 2017-02-09 → 2017-02-07 A (-2d) | 2017-02-09 → 2017-02-08 A (-1d) |  | 0% → 100% | 0d → none | baseline start none → 2017-02-09; baseline finish none → 2017-02-09 |
| 23 | Delivery of complementary content by client | 2017-03-02 → 2017-02-28 (-2d) | 2017-03-02 → 2017-02-28 (-2d) |  |  | 2d → 3.5d | baseline start none → 2017-03-02; baseline finish none → 2017-03-02 |
| 24 | Integration of complementary content | 2017-03-07 → 2017-03-03 (-4d) | 2017-03-08 → 2017-03-06 (-2d) |  |  | 0d → 1.5d | baseline start none → 2017-03-07; baseline finish none → 2017-03-08 |
| 25 | **TESTING & ACCEPTANCE** | 2017-01-24 → 2017-01-20 A (-4d) | 2017-03-29 → 2017-03-27 (-2d) | 47d → 46.5d | 0% → 52% | 0d → 1.5d | baseline start none → 2017-01-24; baseline finish none → 2017-03-29 |
| 26 | Prepare test plan and test cases | 2017-01-24 → 2017-01-20 A (-4d) | 2017-01-30 → 2017-01-27 A (-3d) |  | 0% → 100% | 0d → none | baseline start none → 2017-01-24; baseline finish none → 2017-01-30 |
| 27 | Internal testing - Alpha version | 2017-01-31 → 2017-01-27 A (-4d) | 2017-02-03 → 2017-02-01 A (-2d) | 4d → 3d | 0% → 100% | 0d → none | baseline start none → 2017-01-31; baseline finish none → 2017-02-03 |
| 28 | Alpha testing by client | 2017-02-13 → 2017-02-09 A (-4d) | 2017-02-14 → 2017-02-13 A (-1d) |  | 0% → 100% | 0d → none | baseline start none → 2017-02-13; baseline finish none → 2017-02-14 |
| 29 | Internal testing - Beta version | 2017-02-24 → 2017-02-22 A (-2d) | 2017-03-01 → 2017-02-27 (-2d) |  | 0% → 25% | 0d → 1.5d | baseline start none → 2017-02-24; baseline finish none → 2017-03-01 |
| 30 | Beta testing by client | 2017-03-10 → 2017-03-08 (-2d) | 2017-03-15 → 2017-03-13 (-2d) |  |  | 0d → 1.5d | baseline start none → 2017-03-10; baseline finish none → 2017-03-15 |
| 31 | Final testing by client | 2017-03-23 → 2017-03-21 (-2d) | 2017-03-24 → 2017-03-22 (-2d) |  |  | 0d → 1.5d | baseline start none → 2017-03-23; baseline finish none → 2017-03-24 |
| 32 | Acceptance by client | 2017-03-29 → 2017-03-27 (-2d) | 2017-03-29 → 2017-03-27 (-2d) |  |  | 0d → 1.5d | baseline start none → 2017-03-29; baseline finish none → 2017-03-29 |
| 33 | DEPLOYMENT AT CLIENT'S SITE | 2017-03-30 → 2017-03-28 (-2d) | 2017-03-31 → 2017-03-29 (-2d) |  |  | 0d → 1.5d | baseline start none → 2017-03-30; baseline finish none → 2017-03-31 |
| 34 | PROJECT MANAGEMENT (After Req'ts WP & before Closure) | 2017-01-09 → 2017-01-06 A (-3d) |  |  | 0% → 55% |  | baseline start none → 2017-01-09; baseline finish none → 2017-03-31 |
| 35 | PROJECT CLOSURE | 2017-04-03 → 2017-03-31 (-3d) |  |  |  |  | baseline start none → 2017-04-03; baseline finish none → 2017-04-03 |
